# 7.5MW Drive

Schedule from MS Project, 2019-07-06 to 2022-08-20, status date 2020-11-11, A marks actual dates.

## Calendars

- propulsion calender: Mon-Wed 08:00-12:00, 13:00-17:00; Thu 08:00-13:00; Fri off; Sat-Sun 08:00-12:00, 13:00-17:00. Exceptions (off unless hours are given): 2019-08-11 (عید قربان), 2019-08-19 (عید غدیر خم), 2019-09-08 to 2019-09-09 (تاسوعا و عاشورا), 2019-10-19 (اربعین), 2019-10-27 to 2019-10-28 (شهادت امام حسن و امام رضا), 2019-11-05 (شهادت امام حسن عسکری), 2019-11-14 (میلاد رسول اکرم), 2020-01-28 (شهادت حضرت فاطمه), 2020-02-11 (22 بهمن), 2020-03-08 (ولادت حضرت علی), 2020-03-19 (روز ملی شدن صنعت نفت), 2020-03-20 to 2020-04-01 (تعطیلات نوروز), 2020-04-08 (نیمه شعبان), 2020-05-14 (شهادت حضرت علی), 2020-05-24 to 2020-05-25 (عید فطر), 2020-06-03 to 2020-06-04 (رحلت امام/قیام 15 خرداد), 2020-06-17 (شهادت امام جعفر صادق), 2020-08-08 (عید غدیر), 2020-08-29 (عاشورا), 2020-10-07 (اربعین), 2020-10-15 (رحلت رسول اکرم), 2020-10-17 (شهادت امام رضا), 2020-10-25 (شهادت امام حسن عسکری), 2020-11-03 (میلاد رسول اکرم), 2021-01-16 (شهادت حضرت فاطمه), 2021-02-10 (22 بهمن), 2021-02-25 (ولادت حضرت علی), 2021-03-11 (مبعث رسول اکرم), 2021-03-19 to 2021-03-20 (روز ملی شدن صنعت نفت و روز آخر سال).

## Schedule

| ID | WBS | Task | Type | Duration | Start | Finish | Predecessors | Complete | Remaining | Baseline start | Baseline finish | Baseline duration | Total slack | Free slack | شروع | پایان |
| --- | --- | --- | --- | --- | --- | --- | --- | --- | --- | --- | --- | --- | --- | --- | --- | --- |
| 1 | 1 | **طراحی و ساخت درایو 15 مگاوات** |  | 877.5d | 2019-07-06 A | 2022-08-20 |  | 46% | 477.61d | 2019-07-06 | 2022-03-05 | 742d | 0d |  | 1398/04/15 | 1400/05/13 |
| 2 | 1.1 | شروع | milestone | 0d | 2019-07-06 A | 2019-07-06 A |  | 100% |  |  |  |  |  |  | 1398/04/15 | 1398/04/15 |
| 3 | 1.2 | ابلاغ قرارداد | milestone | 0d | 2019-07-06 A | 2019-07-06 A | 2 | 100% |  | 2019-07-06 | 2019-07-06 | 0d |  |  | 1398/04/15 | 1398/04/15 |
| 4 | 1.3 | تامین منابع مالی | milestone | 0d | 2019-07-06 | 2022-08-20 | 3 |  |  | 2019-07-06 | 2019-07-06 | 0d | 0d |  | 1398/04/15 | 1398/04/15 |
| 5 | 1.4 | تهیه برنامه زمانبندی |  | 90d | 2019-07-06 A | 2019-11-03 A | 4 | 100% |  | 2019-07-06 | 2019-11-03 | 90d |  |  | 1398/04/15 | 1398/08/12 |
| 6 | 1.5 | تایید برنامه زمانبندی |  | 2d | 2019-11-03 A | 2019-11-06 A | 5 | 100% |  | 2019-11-03 | 2019-11-06 | 2d |  |  | 1398/08/12 | 1398/08/15 |
| 7 | 1.6 | **مطالعات** |  | 87d | 2019-11-06 A | 2020-02-25 A |  | 100% |  | 2019-11-06 | 2020-02-25 | 87d |  |  | 1398/08/15 | 1398/12/06 |
| 8 | 1.6.1 | مطالعه ساختار قدرت |  | 35d | 2019-11-06 A | 2019-12-21 A | 6 | 100% |  | 2019-11-06 | 2019-12-21 | 35d |  |  | 1398/08/15 | 1398/09/30 |
| 9 | 1.6.2 | انتخاب ساختار قدرت |  | 2d | 2019-12-21 A | 2019-12-23 A | 8 | 100% |  | 2019-12-21 | 2019-12-23 | 2d |  |  | 1398/09/30 | 1398/10/02 |
| 10 | 1.6.3 | مطالعه ساختار کنترل |  | 30d | 2019-12-23 A | 2020-01-30 A | 9 | 100% |  | 2019-12-23 | 2020-01-30 | 30d |  |  | 1398/10/02 | 1398/11/10 |
| 11 | 1.6.4 | انتخاب ساختار کنترل |  | 10d | 2020-01-30 A | 2020-02-13 A | 10 | 100% |  | 2020-01-30 | 2020-02-13 | 10d |  |  | 1398/11/10 | 1398/11/24 |
| 12 | 1.6.5 | مطالعه و انتخاب سیستم خنک سازی |  | 10d | 2020-02-13 A | 2020-02-25 A | 11 | 100% |  | 2020-02-13 | 2020-02-25 | 10d |  |  | 1398/11/24 | 1398/12/06 |
| 13 | 1.7 | **طراحی و محاسبات** |  | 80d | 2019-12-23 A | 2020-04-20 A |  | 100% |  | 2019-12-23 | 2020-06-21 | 125d |  |  | 1398/10/02 | 1399/02/01 |
| 14 | 1.7.1 | طراحی اینورتر |  | 40d | 2019-12-23 A | 2020-02-13 A | 9, 8 | 100% |  | 2019-12-23 | 2020-02-13 | 40d |  |  | 1398/10/02 | 1398/11/24 |
| 15 | 1.7.2 | طراحی رکتیفایر |  | 30d | 2019-12-23 A | 2020-01-30 A | 9 | 100% |  | 2019-12-23 | 2020-01-30 | 30d |  |  | 1398/10/02 | 1398/11/10 |
| 16 | 1.7.3 | طراحی ترانسفورماتور |  | 30d | 2019-12-23 A | 2020-01-30 A | 9 | 100% |  | 2019-12-23 | 2020-01-30 | 30d |  |  | 1398/10/02 | 1398/11/10 |
| 17 | 1.7.4 | طراحی کنترل |  | 30d | 2020-02-13 A | 2020-04-06 A | 10, 11 | 100% |  | 2020-02-13 | 2020-04-06 | 30d |  |  | 1398/11/24 | 1399/01/18 |
| 18 | 1.7.5 | طراحی حفاظت |  | 10d | 2020-04-06 A | 2020-04-20 A | 17 | 100% |  | 2020-04-06 | 2020-04-20 | 10d |  |  | 1399/01/18 | 1399/02/01 |
| 19 | 1.7.6 | طراحی خنک سازی |  | 6d | 2020-02-26 A | 2020-03-04 A | 14, 15, 12 | 100% |  | 2020-02-26 | 2020-03-04 | 6d |  |  | 1398/12/07 | 1398/12/14 |
| 20 | 1.8 | تامین نمونه آزمایشگاهی 120 کیلووات |  | 3d | 2020-02-13 A | 2020-02-17 A | 14, 15, 16 | 100% |  | 2020-02-13 | 2020-02-17 | 3d |  |  | 1398/11/24 | 1398/11/28 |
| 21 | 1.9 | ساخت نمونه آزمایشگاهی 120 کیلووات |  | 12d | 2020-02-17 A | 2020-03-03 A | 20 | 100% |  | 2020-02-17 | 2020-03-03 | 12d |  |  | 1398/11/28 | 1398/12/13 |
| 22 | 1.10 | تست نمونه آزمایشگاهی 120 کیلووات |  | 70d | 2020-03-03 A | 2020-06-21 A | 21 | 100% |  | 2020-03-03 | 2020-06-21 | 70d |  |  | 1398/12/13 | 1399/04/01 |
| 23 | 1.11 | تامین قطعات 2.5 مگاوات اول |  | 73d | 2020-06-21 A | 2020-09-22 | 22 | 92% | 5.84d | 2020-02-13 | 2020-06-06 | 73d | 46d | 0d | 1399/04/01 | 1399/07/01 |
| 24 | 1.12 | **ساخت و مونتاژ 2.5 مگاوات اول** |  | 175d | 2020-09-22 | 2021-05-09 |  |  |  | 2020-06-06 | 2021-01-19 | 175d | 305.5d |  | 1399/07/01 | 1400/02/19 |
| 25 | 1.12.1 | **ساخت و مونتاژ بخش قدرت** |  | 175d | 2020-09-22 | 2021-05-09 |  |  |  | 2020-06-06 | 2021-01-19 | 175d | 305.5d |  | 1399/07/01 | 1400/02/19 |
| 26 | 1.12.1.1 | مونتاژ کلی ماژول ها در تابلوی اینورتر |  | 35d | 2020-09-22 | 2020-11-10 | 23 |  |  | 2020-06-06 | 2020-07-20 | 35d | 305.5d | 0d | 1399/07/01 | 1399/08/20 |
| 27 | 1.12.1.2 | مونتاژ تابلوی فیلتر خروجی |  | 35d | 2020-09-22 | 2020-11-10 | 23 |  |  | 2020-06-06 | 2020-07-20 | 35d | 445.5d | 140d | 1399/07/01 | 1399/08/20 |
| 28 | 1.12.1.3 | مونتاژتابلوی مدارترمزی |  | 35d | 2020-09-22 | 2020-11-10 | 23 |  |  | 2020-06-06 | 2020-07-20 | 35d | 445.5d | 140d | 1399/07/01 | 1399/08/20 |
| 29 | 1.12.1.4 | انجام کابل کشی،شین کشی و سیم کشی های اینورتر |  | 35d | 2020-11-11 | 2020-12-24 | 26 |  |  | 2020-07-20 | 2020-09-03 | 35d | 305.5d | 0d | 1399/08/21 | 1399/10/04 |
| 30 | 1.12.1.5 | مونتاژ جداگانه ماژول های رکتیفایر |  | 35d | 2020-12-24 | 2021-02-07 | 29 |  |  | 2020-09-05 | 2020-10-20 | 35d | 305.5d | 0d | 1399/10/04 | 1399/11/19 |
| 31 | 1.12.1.6 | مونتاژ کلی ماژول ها در تابلوی رکتیفایر |  | 35d | 2021-02-07 | 2021-03-27 | 30 |  |  | 2020-10-20 | 2020-12-06 | 35d | 305.5d | 0d | 1399/11/19 | 1400/01/07 |
| 32 | 1.12.1.7 | انجام کابل کشی،شین کشی و سیم کشی های رکتیفایر |  | 35d | 2021-03-27 | 2021-05-09 | 31 |  |  | 2020-12-06 | 2021-01-19 | 35d | 305.5d | 0d | 1400/01/07 | 1400/02/19 |
| 33 | 1.12.1.8 | مونتاژ بخش های مختلف ترانسفورماتور |  | 35d | 2020-09-22 | 2020-11-10 | 23 |  |  | 2020-06-06 | 2020-07-20 | 35d | 410.5d | 0d | 1399/07/01 | 1399/08/20 |
| 34 | 1.12.1.9 | قرار دادن بخش های مختلف ترانسفورماتور در مخزن یا تابلو |  | 35d | 2020-11-11 | 2020-12-24 | 33 |  |  | 2020-07-20 | 2020-09-03 | 35d | 410.5d | 105d | 1399/08/21 | 1399/10/04 |

| ID | WBS | Task | Type | Duration | Start | Finish | Predecessors | Complete | Remaining | Baseline start | Baseline finish | Baseline duration | Total slack | Free slack | شروع | پایان |
| --- | --- | --- | --- | --- | --- | --- | --- | --- | --- | --- | --- | --- | --- | --- | --- | --- |
| 35 | 1.12.2 | **ساخت و مونتاژ بخش کنترل** |  | 30d | 2020-09-22 | 2020-11-04 |  |  |  | 2020-06-06 | 2020-07-13 | 30d | 450.5d |  | 1399/07/01 | 1399/08/14 |
| 36 | 1.12.2.1 | مونتاژبردهای کنترلی |  | 20d | 2020-09-22 | 2020-10-20 | 23 |  |  | 2020-06-06 | 2020-07-01 | 20d | 450.5d | 0d | 1399/07/01 | 1399/07/29 |
| 37 | 1.12.2.2 | قراردادن بردهای کنترلی در تابلو |  | 10d | 2020-10-20 | 2020-11-04 | 36 |  |  | 2020-07-01 | 2020-07-13 | 10d | 450.5d | 145d | 1399/07/29 | 1399/08/14 |
| 38 | 1.13 | تامین و تدارکات دو ماژول 2.5 مگاوات دوم |  | 50d | 2020-09-22 A | 2020-11-30 | 23 | 92% | 4d | 2020-06-06 | 2020-08-09 | 50d | 380.5d | 17d | 1399/07/01 | 1399/09/10 |
| 39 | 1.14 | ساخت و مونتاژ دو ماژول 2.5 مگاوات دوم |  | 120d | 2020-12-21 | 2021-05-24 | 23SS+140d, 38 |  |  | 2020-08-31 | 2021-02-03 | 120d | 363.5d | 58d | 1399/10/01 | 1400/03/03 |
| 40 | 1.15 | **تست کارگاهی** |  | 70d | 2021-05-10 | 2021-08-04 |  |  |  | 2021-01-19 | 2021-04-20 | 70d | 305.5d |  | 1400/02/20 | 1400/05/13 |
| 41 | 1.15.1 | **تست اجزای سیستم به صورت جداگانه** |  | 30d | 2021-05-10 | 2021-06-15 |  |  |  | 2021-01-19 | 2021-02-28 | 30d | 305.5d |  | 1400/02/20 | 1400/03/25 |
| 42 | 1.15.1.1 | تست های اولیه اینورتر |  | 30d | 2021-05-10 | 2021-06-15 | 26, 27, 28, 29, 30, 31, 32, 33, 34, 36, 37 |  |  | 2021-01-19 | 2021-02-28 | 30d | 325.5d | 20d | 1400/02/20 | 1400/03/25 |
| 43 | 1.15.1.2 | تست های اولیه رکتیفایر |  | 30d | 2021-05-10 | 2021-06-15 | 26, 27, 28, 29, 30, 31, 32, 33, 34, 36, 37 |  |  | 2021-01-19 | 2021-02-28 | 30d | 325.5d | 20d | 1400/02/20 | 1400/03/25 |
| 44 | 1.15.1.3 | تست های اولیه ترانسفورماتور |  | 30d | 2021-05-10 | 2021-06-15 | 34, 26, 27, 28, 29, 30, 31, 32, 33, 36, 37 |  |  | 2021-01-19 | 2021-02-28 | 30d | 305.5d | 0d | 1400/02/20 | 1400/03/25 |
| 45 | 1.15.2 | **تست کلی سیستم** |  | 40d | 2021-06-15 | 2021-08-04 |  |  |  | 2021-02-28 | 2021-04-20 | 40d | 305.5d |  | 1400/03/25 | 1400/05/13 |
| 46 | 1.15.2.1 | فراهم کردن بستر تست مناسب |  | 20d | 2021-06-15 | 2021-07-11 | 44 |  |  | 2021-02-28 | 2021-03-27 | 20d | 305.5d | 0d | 1400/03/25 | 1400/04/20 |
| 47 | 1.15.2.2 | تست کل سیستم در ولتاژ نامی جریان پایین |  | 20d | 2021-07-11 | 2021-08-04 | 42, 43, 44, 46 |  |  | 2021-03-27 | 2021-04-20 | 20d | 305.5d | 0d | 1400/04/20 | 1400/05/13 |
| 48 | 1.15.2.3 | تست کل سیستم در جریان نامی ولتاژ پایین |  | 20d | 2021-07-11 | 2021-08-04 | 42, 43, 44, 46 |  |  | 2021-02-28 | 2021-03-27 | 20d | 305.5d | 0d | 1400/04/20 | 1400/05/13 |
| 49 | 1.16 | پایان | milestone | 0d | 2021-08-04 | 2021-08-04 | 39, 47, 48, 18, 19 |  |  | 2022-03-05 | 2022-03-05 | 0d | 305.5d |  | 1400/05/13 | 1400/05/13 |
